# Plan PRs

How a schedule from MS Project changed from version to version. A marks actual dates.

## Version 1 (saved 2006-09-21, file 20060921-1158854614.mpp)

| ID | WBS | Task | Duration | Start | Finish | Predecessors | Complete | Total float | Constraint |
| --- | --- | --- | --- | --- | --- | --- | --- | --- | --- |
| 1 | 1 | **Foto XS - PR´s** | 50d | 2006-09-04 08:00 A | 2006-11-13 17:00 |  | 20% | 0d |  |
| 2 | 1.1 | **Configuración y Desarrollo** | 47d | 2006-09-05 08:00 A | 2006-11-09 17:00 |  | 30% | 2d |  |
| 3 |  | PR 329 | 0.25d | 2006-09-05 08:00 A | 2006-09-05 10:00 A |  | 100% |  | start no earlier than 2006-09-05 08:00 |
| 4 |  | PR 87 | 0.25d | 2006-09-05 08:00 A | 2006-09-05 10:00 A |  | 100% |  | start no earlier than 2006-09-05 08:00 |
| 5 |  | PR 259 | 0.25d | 2006-09-05 08:00 A | 2006-09-05 10:00 A |  | 100% |  | start no earlier than 2006-09-05 08:00 |
| 6 |  | PR 276 | 0.25d | 2006-09-05 08:00 A | 2006-09-05 10:00 A |  | 100% |  | start no earlier than 2006-09-05 08:00 |
| 7 |  | PR 304 | 0.25d | 2006-09-06 08:00 A | 2006-09-06 10:00 A |  | 100% |  | start no earlier than 2006-09-06 08:00 |
| 8 |  | PR 337 | 0.5d | 2006-09-06 08:00 A | 2006-09-06 12:00 A |  | 100% |  | start no earlier than 2006-09-06 08:00 |
| 9 |  | PR 256 | 0.5d | 2006-09-06 08:00 A | 2006-09-06 12:00 A |  | 100% |  | start no earlier than 2006-09-06 08:00 |
| 10 |  | PR 22 | 0.25d | 2006-09-07 08:00 A | 2006-09-07 10:00 A |  | 100% |  | start no earlier than 2006-09-07 08:00 |
| 11 |  | PR 59 | 0.25d | 2006-09-07 08:00 A | 2006-09-07 10:00 A |  | 100% |  | start no earlier than 2006-09-07 08:00 |
| 12 |  | PR 5 | 0.25d | 2006-09-07 08:00 A | 2006-09-07 10:00 A |  | 100% |  | start no earlier than 2006-09-07 08:00 |
| 13 |  | PR 278 | 1d | 2006-09-08 08:00 A | 2006-09-08 17:00 A |  | 100% |  | start no earlier than 2006-09-08 08:00 |
| 14 |  | PR 240 | 0.5d | 2006-09-11 08:00 A | 2006-09-11 12:00 A |  | 100% |  | start no earlier than 2006-09-11 08:00 |
| 15 |  | PR 258 | 0.5d | 2006-09-11 08:00 A | 2006-09-11 12:00 A |  | 100% |  | start no earlier than 2006-09-11 08:00 |
| 16 |  | PR 268 | 0.75d | 2006-09-13 08:00 A | 2006-09-13 15:00 A |  | 100% |  | start no earlier than 2006-09-13 08:00 |
| 17 |  | PR 7 | 0.5d | 2006-09-14 08:00 A | 2006-09-14 12:00 A |  | 100% |  | start no earlier than 2006-09-14 08:00 |
| 18 |  | PR 89 | 0.5d | 2006-09-15 08:00 A | 2006-09-15 12:00 A |  | 100% |  | start no earlier than 2006-09-15 08:00 |
| 19 |  | PR 17 | 0.75d | 2006-09-18 08:00 A | 2006-09-18 15:00 A |  | 100% |  | start no earlier than 2006-09-18 08:00 |
| 20 |  | PR 372 | 8d | 2006-09-18 08:00 A | 2006-09-27 17:00 |  | 50% | 32d | start no earlier than 2006-09-18 08:00 |
| 21 |  | PR 91 / 226 | 0.5d | 2006-09-19 08:00 A | 2006-09-19 12:00 |  | 90% | 38.5d | start no earlier than 2006-09-19 08:00 |
| 22 |  | PR 241 | 2.5d | 2006-09-19 08:00 A | 2006-09-21 12:00 |  | 80% | 36.5d | start no earlier than 2006-09-19 08:00 |
| 23 |  | PR 94 | 0.25d | 2006-09-19 08:00 A | 2006-09-19 10:00 A |  | 100% |  | start no earlier than 2006-09-19 08:00 |
| 24 |  | PR 280 | 0.25d | 2006-09-20 08:00 A | 2006-09-20 10:00 A |  | 100% |  | start no earlier than 2006-09-20 08:00 |
| 25 |  | PR 96 | 0.25d | 2006-09-20 08:00 A | 2006-09-20 10:00 A |  | 100% |  | start no earlier than 2006-09-20 08:00 |
| 26 |  | PR 103 | 1.5d | 2006-09-21 08:00 | 2006-09-22 12:00 |  |  | 35.5d | start no earlier than 2006-09-21 08:00 |
| 27 |  | PR 10 | 0.5d | 2006-09-22 08:00 | 2006-09-22 12:00 |  |  | 41.5d | start no earlier than 2006-09-22 08:00 |
| 28 |  | PR 193 | 0.25d | 2006-09-26 08:00 | 2006-09-26 10:00 |  |  | 33.75d | start no earlier than 2006-09-26 08:00 |
| 29 |  | PR 3 | 5d | 2006-09-29 08:00 | 2006-10-05 17:00 |  |  | 26d | start no earlier than 2006-09-29 08:00 |
| 30 |  | PR 117 | 2d | 2006-10-09 08:00 | 2006-10-10 17:00 |  |  | 1d | start no earlier than 2006-10-09 08:00 |
| 31 |  | PR 273 | 1d | 2006-10-11 08:00 | 2006-10-11 17:00 | 30 |  | 1d |  |
| 32 |  | PR 132 | 1d | 2006-10-13 08:00 | 2006-10-13 17:00 | 31 |  | 1d |  |
| 33 |  | PR 331 | 1d | 2006-10-16 08:00 | 2006-10-16 17:00 | 32 |  | 1d |  |
| 34 |  | PR 62 | 1d | 2006-10-17 08:00 | 2006-10-17 17:00 | 33 |  | 1d |  |
| 35 |  | PR 106 | 1d | 2006-10-18 08:00 | 2006-10-18 17:00 | 34 |  | 1d |  |
| 36 |  | PR 102 | 1d | 2006-10-19 08:00 | 2006-10-19 17:00 | 35 |  | 1d |  |
| 37 |  | PR 185 | 1d | 2006-10-20 08:00 | 2006-10-20 17:00 | 36 |  | 1d |  |
| 38 |  | PR 14 | 1d | 2006-10-23 08:00 | 2006-10-23 17:00 | 37 |  | 1d |  |
| 39 |  | PR 98 | 1d | 2006-10-24 08:00 | 2006-10-24 17:00 | 38 |  | 1d |  |
| 40 |  | PR 90 | 1d | 2006-10-25 08:00 | 2006-10-25 17:00 | 39 |  | 1d |  |
| 41 |  | PR 153 | 1d | 2006-10-26 08:00 | 2006-10-26 17:00 | 40 |  | 1d |  |
| 42 |  | PR 15 | 1d | 2006-10-27 08:00 | 2006-10-27 17:00 | 41 |  | 1d |  |
| 43 |  | PR 261 | 1d | 2006-10-30 08:00 | 2006-10-30 17:00 | 42 |  | 1d |  |
| 44 |  | PR 8 | 1d | 2006-10-31 08:00 | 2006-10-31 17:00 | 43 |  | 1d |  |
| 45 |  | PR 12 | 1d | 2006-11-01 08:00 | 2006-11-01 17:00 | 44 |  | 1d |  |
| 46 |  | PR 18 | 1d | 2006-11-02 08:00 | 2006-11-02 17:00 | 45 |  | 1d |  |
| 47 |  | PR 21 | 1d | 2006-11-03 08:00 | 2006-11-03 17:00 | 46 |  | 1d |  |
| 48 |  | PR 175 | 1d | 2006-11-06 08:00 | 2006-11-06 17:00 | 47 |  | 1d |  |
| 49 |  | PR 54 | 1d | 2006-11-07 08:00 | 2006-11-07 17:00 | 48 |  | 1d |  |
| 50 |  | PR 377 | 1d | 2006-11-08 08:00 | 2006-11-08 17:00 | 49 |  | 2d |  |
| 51 |  | PR 316 | 1d | 2006-11-09 08:00 | 2006-11-09 17:00 | 50 |  | 2d |  |
| 52 |  | Ajustes recomendados | 5d | 2006-09-04 08:00 | 2006-09-08 17:00 |  |  | 45d |  |
| 53 | 1.3 | **Gerencia de Proyecto** | 45d | 2006-09-11 08:00 | 2006-11-13 17:00 |  |  | 0d |  |
| 54 |  | Planificación | 15d | 2006-09-12 08:00 | 2006-10-02 17:00 |  |  | 29d | start no earlier than 2006-09-12 08:00 |
| 55 | 1.3.2 | **Control y Seguimiento** | 34.5d | 2006-09-11 08:00 | 2006-10-30 12:00 |  |  | 10.5d |  |
| 56 |  | 11-09 | 0.5d | 2006-09-11 08:00 | 2006-09-11 12:00 |  |  | 44.5d | start no earlier than 2006-09-11 08:00 |
| 57 |  | 18-09 | 0.5d | 2006-09-18 08:00 | 2006-09-18 12:00 |  |  | 39.5d | start no earlier than 2006-09-18 08:00 |
| 58 |  | 25-09 | 0.5d | 2006-09-25 08:00 | 2006-09-25 12:00 |  |  | 34.5d | start no earlier than 2006-09-25 08:00 |
| 59 |  | 02-10 | 0.5d | 2006-10-02 08:00 | 2006-10-02 12:00 |  |  | 29.5d | start no earlier than 2006-10-02 08:00 |
| 60 |  | 09-10 | 0.5d | 2006-10-09 08:00 | 2006-10-09 12:00 |  |  | 24.5d | start no earlier than 2006-10-09 08:00 |
| 61 |  | 16-10 | 0.5d | 2006-10-16 08:00 | 2006-10-16 12:00 |  |  | 20.5d | start no earlier than 2006-10-16 08:00 |
| 62 |  | 23-10 | 0.5d | 2006-10-23 08:00 | 2006-10-23 12:00 |  |  | 15.5d | start no earlier than 2006-10-23 08:00 |
| 63 |  | 30-10 | 0.5d | 2006-10-30 08:00 | 2006-10-30 12:00 |  |  | 10.5d | start no earlier than 2006-10-30 08:00 |
| 64 |  | Cierre | 1d | 2006-11-13 08:00 | 2006-11-13 17:00 | 51 |  | 0d | start no earlier than 2006-11-13 08:00 |

## Version 2 (saved 2006-10-20, file 20061020-1161351060.mpp)

Last finish 2006-11-13 → 2006-11-15 (+2d). Complete tasks 20 → 32.

Added:

| ID | Task | Duration | Start | Finish | Predecessors | Resources |
| --- | --- | --- | --- | --- | --- | --- |
| 30 | PR 93 | 1d | 2006-10-25 08:00 A | 2006-10-25 17:00 A | 29 | Gustavo |
| 34 | PR 170 | 1d | 2006-10-24 08:00 A | 2006-10-24 17:00 A | 33 | Gustavo |

Removed: 21 PR 91 / 226; 32 PR 132; 33 PR 331; 34 PR 62; 41 PR 153; 42 PR 15; 45 PR 12; 48 PR 175; 49 PR 54; 50 PR 377; 51 PR 316

Changed:

| ID | Task | Start | Finish | Duration | Complete | Total float | Predecessors | Other |
| --- | --- | --- | --- | --- | --- | --- | --- | --- |
| 1 | **Foto XS - PR´s** | 2006-09-04 08:00 A → 2006-09-05 08:00 A (+1d) | 2006-11-13 17:00 → 2006-11-15 12:00 (+2d) | 50d → 50.5d | 20% → 45% |  |  |  |
| 2 | **Configuración y Desarrollo** |  | 2006-11-09 17:00 → 2006-11-08 12:00 (-1d) | 47d → 45.5d | 30% → 74% | 2d → 0d |  |  |
| 20 | PR 372 |  | 2006-09-27 17:00 A |  | 50% → 100% | 32d → none |  |  |
| 24 | PR 103 | 2006-09-21 08:00 A | 2006-09-22 12:00 A |  | 0% → 100% | 35.5d → none |  |  |
| 25 | PR 10 | 2006-09-22 08:00 A | 2006-09-22 12:00 A |  | 0% → 100% | 41.5d → none |  |  |
| 26 | PR 193 | 2006-09-26 08:00 A | 2006-09-26 10:00 A |  | 0% → 100% | 33.75d → none |  |  |
| 27 | PR 117 | 2006-10-09 08:00 A | 2006-10-10 17:00 A |  | 0% → 100% | 1d → none |  |  |
| 28 | PR 273 | 2006-10-11 08:00 A | 2006-10-11 17:00 A |  | 0% → 100% | 1d → none |  |  |
| 29 | PR 102 | 2006-10-19 08:00 → 2006-10-17 08:00 A (-2d) | 2006-10-19 17:00 → 2006-10-17 17:00 A (-2d) |  | 0% → 100% | 1d → none | 39 → 28 |  |
| 31 | PR 185 | 2006-10-20 08:00 → 2006-10-18 08:00 A (-2d) | 2006-10-20 17:00 → 2006-10-18 17:00 A (-2d) |  | 0% → 100% | 1d → none | 29 → 30 |  |
| 32 | PR 14 | 2006-10-23 08:00 → 2006-10-19 08:00 A (-4d) | 2006-10-23 17:00 → 2006-10-19 17:00 A (-4d) |  | 0% → 100% | 1d → none |  |  |
| 33 | PR 21 | 2006-11-03 08:00 → 2006-11-01 08:00 A (-2d) | 2006-11-03 17:00 → 2006-11-01 17:00 A (-2d) |  | 0% → 100% | 1d → none | 37 → 32 |  |
| 35 | PR 241 |  | 2006-09-21 12:00 → 2006-10-25 12:00 (+34d) |  |  | 36.5d → 0d | none → 34 |  |
| 36 | PR 261 | 2006-10-30 08:00 → 2006-10-25 13:00 (-5d) | 2006-10-30 17:00 → 2006-10-26 12:00 (-4d) |  |  | 1d → 0d | PR 15 → 35 |  |
| 37 | PR 18 | 2006-11-02 08:00 → 2006-10-26 13:00 (-7d) | 2006-11-02 17:00 → 2006-10-27 12:00 (-6d) |  |  | 1d → 0d | PR 12 → 36 |  |
| 38 | PR 3 | 2006-09-29 08:00 → 2006-10-27 13:00 (+28d) | 2006-10-05 17:00 → 2006-11-03 12:00 (+29d) |  |  | 26d → 0d | none → 37 | resources Gustavo → Gustavo; Beta |
| 39 | PR 106 | 2006-10-18 08:00 → 2006-11-03 13:00 (+16d) | 2006-10-18 17:00 → 2006-11-03 17:00 (+16d) | 1d → 0.5d |  | 1d → 0d | PR 62 → 38 |  |
| 40 | PR 90 | 2006-10-25 08:00 → 2006-11-06 08:00 (+12d) | 2006-10-25 17:00 → 2006-11-06 12:00 (+12d) | 1d → 0.5d |  | 1d → 0d | 41 → 39 |  |
| 41 | PR 98 | 2006-10-24 08:00 → 2006-11-06 13:00 (+13d) | 2006-10-24 17:00 → 2006-11-07 12:00 (+14d) |  |  | 1d → 0d | 32 → 40 |  |
| 42 | PR 8 | 2006-10-31 08:00 → 2006-11-07 13:00 (+7d) | 2006-10-31 17:00 → 2006-11-08 12:00 (+8d) |  |  | 1d → 0d | 36 → 41 |  |
| 43 | Ajustes recomendados | 2006-09-04 08:00 → 2006-11-08 13:00 (+65d) | 2006-09-08 17:00 → 2006-11-15 12:00 (+68d) |  |  | 45d → 0d | none → 2 |  |
| 55 | Cierre |  |  |  |  | 0d → 1.5d | PR 316 → none |  |
